# Simple Project Plan

Schedule from MS Project, 2018-04-03 to 2019-12-31.

## Calendars

- Standard: Mon-Fri 08:00-12:00, 13:00-17:00; Sat-Sun off.

## Resources

| Resource | Group |
| --- | --- |
| Palvelinympäristön hankintaryhmän jäsen | Palvelinympäristön hankintaryhmä |
| Pääkäyttäjäryhmän jäsen | Pääkäyttäjäryhmä |
| Palvelinympäristön hankintaryhmän vetäjä | Palvelinympäristön hankintaryhmä |
| Pääkäyttäjäryhmän vetäjä | Pääkäyttäjäryhmä |
| Syksyn 2018 pilottikirjaston testaaja | Syksyn 2018 Pilottikirjaston ryhmä |
| Syksyn 2018 pilottikirjaston pääkäyttäjä | Syksyn 2018 pilottikirjaston ryhmä |
| Joulun 2018 pilottikirjaston testaaja | Joulun 2018 Pilottikirjaston ryhmä |
| Joulun 2018 pilottikirjaston pääkäyttäjä | Joulun 2018 pilottikirjaston ryhmä |
| Kehittäjäryhmän jäsen | Kehittäjäryhmä |

## Schedule

| ID | WBS | Task | Duration | Start | Finish | Predecessors | Total slack | Free slack | Constraint | Resources | Work |
| --- | --- | --- | --- | --- | --- | --- | --- | --- | --- | --- | --- |
| 1 | 1 | **Tukitehtävät** | 452d | 2018-04-09 | 2019-12-31 |  | 0d |  |  |  |  |
| 2 | 1.1 | Projektin koordinointi | 452d | 2018-04-09 | 2019-12-31 |  | 0d |  | finish no earlier than 2019-12-31 |  |  |
| 3 | 2 | **Testikäytön valmistelut** | 125d? | 2018-04-09 | 2018-09-28 |  | 327d |  |  |  | 2592h |
| 4 | 2.1 | **Testi-, pilotti- ja tuotantoympäristöjen määrittely** | 125d? | 2018-04-09 | 2018-09-28 |  | 327d |  |  |  | 2000h |
| 5 | 2.1.1 | Palvelinympäristön hankinta | 125d? | 2018-04-09 | 2018-09-28 |  | 327d |  | start no earlier than 2018-04-09 | Palvelinympäristön hankintaryhmän jäsen; Palvelinympäristön hankintaryhmän vetäjä | 2000h |
| 6 | 2.2 | Migraation suunnittelu | 20d | 2018-04-23 | 2018-05-18 |  | 422d |  | start no earlier than 2018-04-23 | Pääkäyttäjäryhmän jäsen; Pääkäyttäjäryhmän vetäjä | 320h |
| 7 | 2.3 | **Testiympäristöjen asennus (erit. Pilottikirjastot)** | 13d | 2018-05-21 | 2018-06-06 |  | 409d |  |  | Pääkäyttäjäryhmän jäsen | 232h |
| 8 | 2.3.1 | Testiympäristöjen datan mappaustaulukot | 4d | 2018-05-21 | 2018-05-24 |  | 418d |  | start no earlier than 2018-05-21 | Pääkäyttäjäryhmän jäsen; Syksyn 2018 pilottikirjaston pääkäyttäjä | 64h |
| 9 | 2.3.2 | Datan siirto testiympäristöihin (erit. Pilottikirjastot) | 5d | 2018-05-28 | 2018-06-01 |  | 409d | 0d | start no earlier than 2018-05-28 | Pääkäyttäjäryhmän jäsen | 40h |
| 10 | 2.3.3 | Testiympäristöjen konfigurointi (erit. Pilottikirjastot) | 3d | 2018-06-04 | 2018-06-06 | 9 | 409d |  | start no earlier than 2018-06-04 | Pääkäyttäjäryhmän jäsen | 24h |
| 11 | 2.4 | Muutostarpeiden raportoinnin ja kriittisten muutosten määrittelyjen käytännöt | 5d | 2018-04-24 | 2018-04-30 |  | 436d |  | start no earlier than 2018-04-24 | Pääkäyttäjäryhmän jäsen | 40h |
| 12 | 3 | **Testikäyttö ja muutostarpeiden määrittely** | 244d? | 2018-04-03 | 2019-03-08 |  | 212d |  |  |  | 4008h |
| 13 | 3.1 | **Toimintojen testaaminen ja muutostarpeiden määrittely** | 89d | 2018-04-03 | 2018-08-03 |  | 367d |  |  | Pääkäyttäjäryhmän jäsen; Pääkäyttäjäryhmän vetäjä | 1424h |
| 14 | 3.1.1 | Kuvailu ja kokoelmien hallinta (testaus ja muutostarpeet) | 89d | 2018-04-03 | 2018-08-03 |  | 367d |  | finish no earlier than 2018-08-03 |  |  |
| 15 | 3.1.2 | Verkkopalvelu - yhteydet Finnaan (testaus ja muutostarpeet) | 89d | 2018-04-03 | 2018-08-03 |  | 367d |  |  |  |  |
| 16 | 3.1.3 | Hankinta (testaus ja muutostarpeet | 89d | 2018-04-03 | 2018-08-03 |  | 367d |  |  |  |  |
| 17 | 3.1.4 | Aineistojen käytön hallinta ja logistiikka (testaus ja muutostarpeiden kartoitus) | 89d | 2018-04-03 | 2018-08-03 |  | 367d |  |  |  |  |
| 18 | 3.1.5 | Järjestelmänhallinta (testaus ja muutostarpeet) | 89d | 2018-04-03 | 2018-08-03 |  | 367d |  |  |  |  |
| 19 | 3.1.6 | Raportointi ja tilastointi (testaus ja muutostarpeet) | 89d | 2018-04-03 | 2018-08-03 |  | 367d |  |  |  |  |
| 20 | 3.1.7 | Standardit ja rajapinnat (testaus ja muutostarpeet) | 89d | 2018-04-03 | 2018-08-03 |  | 367d |  |  |  |  |
| 21 | 3.1.8 | Tietoturvan vaatimat muutostarpeet | 89d | 2018-04-03 | 2018-08-03 |  | 367d |  |  |  |  |
| 22 | 3.2 | Testaaminen pilottikirjastoissa (datan ja toiminnallisuuksien testaus) | 15d | 2018-06-11 | 2018-06-29 |  | 392d |  | finish no earlier than 2018-06-29 | Syksyn 2018 pilottikirjaston testaaja | 120h |
| 23 | 3.3 | Pilottikirjastojen käyttöönoton kannalta kriittisten muutosten määrittely | 10d | 2018-08-06 | 2018-08-17 |  | 357d |  | start no earlier than 2018-08-06 | Pääkäyttäjäryhmän jäsen; Pääkäyttäjäryhmän vetäjä; Syksyn 2018 pilottikirjaston pääkäyttäjä | 240h |
| 24 | 3.4 | Vuodenvaihteen 2018-2019 käyttöönottojen kannalta kriittisten muutosten määrittely | 10d | 2018-11-01 | 2018-11-14 |  | 294d |  | finish no earlier than 2018-11-14 |  |  |
| 25 | 3.5 | Kesän 2019 käyttöönottojen kannalta kriittisten muutosten määrittely | 20d | 2019-02-11 | 2019-03-08 |  | 212d |  | finish no earlier than 2019-03-08 |  |  |

Notes:
- 3: This is a summary task. Use summary tasks to help organize your project into sections.

| ID | WBS | Task | Duration | Start | Finish | Predecessors | Total slack | Free slack | Constraint | Resources | Work |
| --- | --- | --- | --- | --- | --- | --- | --- | --- | --- | --- | --- |
| 26 | 3.6 | **syksyn 2018 pilottikirjastojen tietokannan siirron valmistelu** | 129d? | 2018-04-03 | 2018-09-28 |  | 327d |  |  | Syksyn 2018 pilottikirjaston pääkäyttäjä; Syksyn 2018 pilottikirjaston testaaja | 2184h |
| 27 | 3.6.1 | Pilottikirjastojen tietokantojen siivoaminen | 1d? | 2018-04-03 | 2018-04-03 |  | 455d |  |  |  |  |
| 28 | 3.6.2 | Pilottikirjastojen tietokantojen koekonversiot | 5d | 2018-09-10 | 2018-09-14 |  | 327d | 0d | start no earlier than 2018-09-10 | Pääkäyttäjäryhmän jäsen | 40h |
| 29 | 3.6.3 | Testaaminen syksyn 2018 pilottikirjastossa (2. koekonverion jälkeinen datan testaaminen) | 10d | 2018-09-17 | 2018-09-28 | 28 | 327d |  |  | Syksyn 2018 pilottikirjaston testaaja | 80h |
| 30 | 3.7 | Käyttäjien kouluttaminen | 5d | 2018-08-13 | 2018-08-17 |  | 357d |  | start no earlier than 2018-08-13 | Syksyn 2018 pilottikirjaston pääkäyttäjä | 40h |
| 31 | 4 | **KOHAn kehittäminen** | 185d? | 2018-08-20 | 2019-05-03 |  | 172d |  |  |  | 160h |
| 32 | 4.1 | Syksyn 2018 pilottikirjastojen käyttöönoton kannalta kriittisten muutosten toteuttaminen | 20d | 2018-08-20 | 2018-09-14 |  | 337d |  | start no earlier than 2018-08-18 | Kehittäjäryhmän jäsen | 160h |
| 33 | 4.2 | Kriittisten muutosten toteuttaminen ennen vuodenvaihteen käyttöönottoja | 22d? | 2018-11-15 | 2018-12-14 |  | 272d |  | finish no earlier than 2018-12-14 |  |  |
| 34 | 4.3 | Kriittisten muutosten toteuttaminen ennen kesän 2019 käyttöönottoja | 40d? | 2019-03-11 | 2019-05-03 |  | 172d |  | finish no earlier than 2019-05-03 |  |  |
| 35 | 5 | **Pilottikäyttö** | 16d | 2018-10-01 | 2018-10-22 |  | 311d |  |  |  | 88h |
| 36 | 5.1 | Tuotantoympäristön asentaminen | 5d | 2018-10-01 | 2018-10-05 |  | 322d |  | finish no earlier than 2018-10-05 |  |  |
| 37 | 5.2 | Pilottien tietokantarakenne ja muut asetukset | 5d | 2018-10-08 | 2018-10-12 |  | 317d |  | start no earlier than 2018-10-08 | Syksyn 2018 pilottikirjaston pääkäyttäjä | 40h |
| 38 | 5.3 | Datan siirto tuotantoympäristöön | 5d | 2018-10-15 | 2018-10-19 |  | 312d |  | start no earlier than 2018-10-15 | Pääkäyttäjäryhmän jäsen | 40h |
| 39 | 5.4 | Järjestelmän käyttöönotto | 1d | 2018-10-22 | 2018-10-22 |  | 311d |  | start no earlier than 2018-10-22 | Syksyn 2018 pilottikirjaston pääkäyttäjä | 8h |
| 40 | 6 | **Pilottikäyttö 2** | 16d | 2018-11-19 | 2018-12-10 |  | 276d |  |  |  | 88h |
| 41 | 6.1 | Tuotantoympäristön asentaminen | 5d | 2018-11-19 | 2018-11-23 |  | 287d |  | finish no earlier than 2018-11-23 |  |  |
| 42 | 6.2 | Pilottien tietokantarakenne ja muut asetukset | 5d | 2018-11-26 | 2018-11-30 |  | 282d |  | finish no earlier than 2018-11-30 | Syksyn 2018 pilottikirjaston pääkäyttäjä | 40h |
| 43 | 6.3 | Datan siirto tuotantoympäristöön | 5d | 2018-12-03 | 2018-12-07 |  | 277d |  | finish no earlier than 2018-12-07 | Pääkäyttäjäryhmän jäsen | 40h |
| 44 | 6.4 | Järjestelmän käyttöönotto | 1d | 2018-12-10 | 2018-12-10 |  | 276d |  | start no earlier than 2018-12-10 | Syksyn 2018 pilottikirjaston pääkäyttäjä | 8h |
| 45 | 7 | **Vuodenvaihteen 2018-2019 käyttöönotot** | 11d | 2018-11-26 | 2018-12-10 |  | 276d |  |  |  | 88h |
| 46 | 7.1 | Tuotantoympäristön asentaminen | 5d | 2018-11-26 | 2018-11-30 |  | 282d |  | finish no earlier than 2018-11-30 |  |  |
| 47 | 7.2 | Pilottien tietokantarakenne ja muut asetukset | 5d | 2018-11-26 | 2018-11-30 |  | 282d |  | finish no earlier than 2018-11-30 | Syksyn 2018 pilottikirjaston pääkäyttäjä | 40h |
| 48 | 7.3 | Datan siirto tuotantoympäristöön | 5d | 2018-12-03 | 2018-12-07 |  | 277d |  | finish no earlier than 2018-12-07 | Pääkäyttäjäryhmän jäsen | 40h |
| 49 | 7.4 | Järjestelmän käyttöönotto | 1d | 2018-12-10 | 2018-12-10 |  | 276d |  | finish no earlier than 2018-12-10 | Syksyn 2018 pilottikirjaston pääkäyttäjä | 8h |
